# ProjektovýPlán-TrénerMentálnychSchopností

Schedule from MS Project, 2010-09-27 to 2010-12-10.

## Calendars

- Standard: Mon-Fri 08:00-12:00, 13:00-17:00; Sat-Sun off. Exceptions (off unless hours are given): 2010-10-02 08:00-12:00, 13:00-17:00, 2010-10-09 08:00-12:00, 13:00-17:00, 2010-10-16 08:00-12:00, 13:00-17:00, 2010-10-23 08:00-12:00, 13:00-17:00, 2010-10-30 08:00-12:00, 13:00-17:00, 2010-11-06 08:00-12:00, 13:00-17:00, 2010-11-13 08:00-12:00, 13:00-17:00, 2010-11-20 08:00-12:00, 13:00-17:00, 2010-11-27 08:00-12:00, 13:00-17:00, 2010-12-04 08:00-12:00, 13:00-17:00.

## Resources

| Resource |
| --- |
| RS |
| MK |
| MB |
| GD |
| PB |
| OU |
| AL |
| 1,3,5,7,9,11 |
| 27 |

## Schedule

| ID | WBS | Task | Duration | Start | Finish | Predecessors | Total slack | Free slack | Constraint | Resources | Work |
| --- | --- | --- | --- | --- | --- | --- | --- | --- | --- | --- | --- |
| 1 | 1 | **Projekt Tréner mentálnych schopností** | 65d? | 2010-09-27 | 2010-12-10 |  | 0d |  |  |  | 1360h |
| 2 | 1.1 | **Pred analýzou** | 6d? | 2010-09-27 | 2010-10-02 |  | 4.29d | 0d |  |  |  |
| 3 | 1.1.1 | Inicializácia projektu | 1d? | 2010-09-27 | 2010-09-27 |  | 4.29d | 0d | start no earlier than 2010-09-27 |  |  |
| 4 | 1.1.2 | Zadefinovanie úloh v tíme | 1d? | 2010-09-28 | 2010-09-28 | 3 | 4.29d | 0d | start no earlier than 2010-09-28 |  |  |
| 5 | 1.1.3 | Zvolenie metódy vývoja | 2d? | 2010-09-29 | 2010-09-30 | 4 | 4.29d | 0d | start no earlier than 2010-09-29 |  |  |
| 6 | 1.1.4 | Motivácia na riešenie problematickej oblasti | 2d? | 2010-10-01 | 2010-10-02 | 5 | 4.29d | 0d | start no earlier than 2010-10-01 |  |  |
| 7 | 1.2 | **Analýza** | 14d? | 2010-10-04 | 2010-10-19 | 2 | 4.29d | 0d |  |  | 528h |
| 8 | 1.2.1 | **Analýza problematickej oblasti** | 8d? | 2010-10-04 | 2010-10-12 |  | 10.29d |  |  |  | 64h |
| 9 | 1.2.1.1 | Štúdium problematickej oblasti | 2d? | 2010-10-04 | 2010-10-05 | 6 | 10.29d | 0d | finish no earlier than 2010-10-05 | RS | 16h |
| 10 | 1.2.1.2 | Finalizácia problematická oblasť | 4d? | 2010-10-06 | 2010-10-09 | 9 | 10.29d | 0d | start no earlier than 2010-10-06 | RS | 32h |
| 11 | 1.2.1.3 | Schválenie a pripomienkovanie analýzy | 2d? | 2010-10-11 | 2010-10-12 | 10 | 10.29d | 6d | start no earlier than 2010-10-11 | MK | 16h |
| 12 | 1.2.2 | **Analýza existujúcich riešení** | 8d? | 2010-10-04 | 2010-10-12 |  | 10.29d |  |  |  | 128h |
| 13 | 1.2.2.1 | Analýza existujúcich riešení | 2d? | 2010-10-04 | 2010-10-05 | 6 | 10.29d | 0d | finish no earlier than 2010-10-05 | MB; GD; PB; OU; AL | 80h |
| 14 | 1.2.2.2 | Finalizácia analýzy existujúcich riešení | 4d? | 2010-10-06 | 2010-10-09 | 13 | 10.29d | 0d | start no earlier than 2010-10-06 | OU | 32h |
| 15 | 1.2.2.3 | Schválenie a pripomienkovanie analýzy | 2d? | 2010-10-11 | 2010-10-12 | 14 | 10.29d | 6d | finish no earlier than 2010-10-12 | MK | 16h |
| 16 | 1.2.3 | **Analýza požiadaviek** | 8d? | 2010-10-04 | 2010-10-12 |  | 4.29d |  |  |  | 160h |
| 17 | 1.2.3.1 | Formulovanie požiadaviek | 2d? | 2010-10-04 | 2010-10-05 | 6 | 4.29d | 0d | finish no earlier than 2010-10-05 | MB; GD; PB; OU; AL; RS; MK | 112h |
| 18 | 1.2.3.2 | Finalizácia požiadaviek | 4d? | 2010-10-06 | 2010-10-09 | 17 | 4.29d | 0d | start no earlier than 2010-10-06 | PB | 32h |
| 19 | 1.2.3.3 | Schválenie a pripomienkovanie požiadaviek | 2d? | 2010-10-11 | 2010-10-12 | 18 | 10.29d | 6d |  | MK | 16h |
| 20 | 1.2.4 | **Analýza technológií** | 8d? | 2010-10-11 | 2010-10-19 |  | 4.29d |  |  |  | 176h |
| 21 | 1.2.4.1 | Analýza platformy | 2d? | 2010-10-11 | 2010-10-12 | 18 | 4.29d | 0d | start no earlier than 2010-10-11 | GD | 16h |
| 22 | 1.2.4.2 | Analýza technológií - architektúra | 6d? | 2010-10-13 | 2010-10-19 | 21 | 4.29d | 0d | start no earlier than 2010-10-06 | MB; AL | 96h |
| 23 | 1.2.4.3 | Analýza technológií - splnenie požiadaviek | 6d? | 2010-10-13 | 2010-10-19 | 21 | 4.29d | 0d | start no earlier than 2010-10-06 | GD | 48h |
| 24 | 1.2.4.4 | Analýza technológií - gui | 2d? | 2010-10-18 | 2010-10-19 |  | 4.29d | 0d | start no earlier than 2010-10-18 | PB | 16h |

| ID | WBS | Task | Duration | Start | Finish | Predecessors | Total slack | Free slack | Constraint | Resources | Work |
| --- | --- | --- | --- | --- | --- | --- | --- | --- | --- | --- | --- |
| 25 | 1.3 | **Návrh** | 10d? | 2010-10-20 | 2010-10-30 | 7 | 4.29d | 3d |  |  | 504h |
| 26 | 1.3.1 | **Funkcionálny návrh** | 10d? | 2010-10-20 | 2010-10-30 |  | 7d |  |  |  | 200h |
| 27 | 1.3.1.1 | Návrh funkcionality, UML prípady použitia | 3d | 2010-10-20 | 2010-10-22 | 11, 15, 19 | 10d | 0d |  | OU | 24h |
| 28 | 1.3.1.2 | Návrh grafického rozhrania | 4d | 2010-10-23 | 2010-10-27 | 27 | 10d |  |  | PB; GD | 64h |
| 29 | 1.3.1.3 | Návrh štruktúry hier | 4d | 2010-10-23 | 2010-10-27 | 27 | 10d |  | start no earlier than 2010-10-16 | PB; GD | 64h |
| 30 | 1.3.1.4 | Finalizácia návrhu funkcionality | 3d? | 2010-10-25 | 2010-10-27 |  | 7d | 0d | finish no earlier than 2010-10-27 | OU | 24h |
| 31 | 1.3.1.5 | Schválenie a pripomienkovanie návrhu funkcionality | 3d | 2010-10-28 | 2010-10-30 | 30 | 7d | 0d | start no earlier than 2010-10-28 | MK | 24h |
| 32 | 1.3.2 | **Architektonický návrh** | 10d? | 2010-10-20 | 2010-10-30 |  | 4d | 0d |  |  | 304h |
| 33 | 1.3.2.1 | Výber technológií pre implementáciu | 0.71d? | 2010-10-20 | 2010-10-20 | 22, 23, 24 | 4.29d | 0d | start no earlier than 2010-10-13 | MB; GD; PB; OU; AL; RS; MK | 40h |
| 34 | 1.3.2.2 | Návrh logickej architektúry, UML diagramy | 6d | 2010-10-20 | 2010-10-27 | 33 | 4.29d | 0d | finish no earlier than 2010-10-20 | OU; MB; AL | 144h |
| 35 | 1.3.2.3 | Hrubý návrh fyzickej architektúry, UML diagramy | 3d | 2010-10-27 | 2010-10-30 | 34 | 4.29d |  | start no earlier than 2010-10-21 | MB; AL | 48h |
| 36 | 1.3.2.4 | Návrh databázy, UML modely | 3d | 2010-10-27 | 2010-10-30 | 34 | 4.29d |  | start no earlier than 2010-10-20 | RS | 24h |
| 37 | 1.3.2.5 | Finalizácia návrhu | 3d? | 2010-10-25 | 2010-10-27 |  | 4d | 0d | finish no earlier than 2010-10-27 | OU | 24h |
| 38 | 1.3.2.6 | Schválenie a pripomienkovanie architektonického návrhu | 3d | 2010-10-28 | 2010-10-30 | 37 | 4d |  | start no earlier than 2010-10-28 | MK | 24h |
| 39 | 1.4 | **Finalizácia dokumentácie** | 3d | 2010-11-01 | 2010-11-03 | 32 | 4d |  |  |  | 88h |
| 40 | 1.4.1 | Finalizácia dokumentácie k analýze a návrhu | 2d | 2010-11-01 | 2010-11-02 | 31 | 33d |  |  | RS; OU | 32h |
| 41 | 1.4.2 | Finalizácia dokumentácie k riadeniu | 2d | 2010-11-01 | 2010-11-02 |  | 33d |  |  | RS; OU | 32h |
| 42 | 1.4.3 | Schválenie a pripomienkovanie odovzdávaných dokumentov | 3d | 2010-11-01 | 2010-11-03 |  | 4d | 0d | finish no earlier than 2010-10-30 | MK | 24h |
| 43 | 1.5 | **Implementácia prototypu** | 24d | 2010-11-04 | 2010-12-01 | 25 | 3d | 0d |  |  |  |
| 44 | 1.5.1 | Inštalácia a konfigurácia vývojového prostredia | 2d | 2010-11-04 | 2010-11-05 | 42 | 4d | 1d | start no earlier than 2010-11-02 |  |  |
| 45 | 1.5.2 | Kostra aplikácie a jadrové API | 3d | 2010-11-08 | 2010-11-10 | 44 | 3d | 0d | start no earlier than 2010-11-08 |  |  |
| 46 | 1.5.3 | Prototyp API aplikačného backendu | 6d | 2010-11-11 | 2010-11-17 | 45 | 3d | 0d |  |  |  |
| 47 | 1.5.4 | Prototyp API databázového backendu | 6d | 2010-11-11 | 2010-11-17 | 45 | 3d | 0d |  |  |  |
| 48 | 1.5.5 | Prototyp API pre správu rozšírení | 6d | 2010-11-11 | 2010-11-17 | 45 | 3d | 0d |  |  |  |
| 49 | 1.5.6 | Protoyp používateľského rozhrania | 6d | 2010-11-18 | 2010-11-24 | 46, 47, 48 | 9d |  |  |  |  |
| 50 | 1.5.7 | Implementácia vzorových hier | 6d | 2010-11-18 | 2010-11-24 | 46, 47, 48 | 3d | 0d |  |  |  |
| 51 | 1.5.8 | Implementácia vybranej funkcionality ako rozšírení | 6d | 2010-11-25 | 2010-12-01 | 50 | 3d | 0d |  |  |  |

| ID | WBS | Task | Duration | Start | Finish | Predecessors | Total slack | Constraint | Resources | Work |
| --- | --- | --- | --- | --- | --- | --- | --- | --- | --- | --- |
| 52 | 1.6 | **Testovanie aplikácie** | 5d | 2010-12-02 | 2010-12-07 | 43 | 3d |  |  |  |
| 53 | 1.6.1 | Testovanie aplikácie | 5d | 2010-12-02 | 2010-12-07 | 51 | 3d |  |  |  |
| 54 | 1.7 | **Nefunkcionálne požiadavky** | 63d? | 2010-09-29 | 2010-12-10 |  | 0d |  |  | 240h |
| 55 | 1.7.1 | Vytvorenie plagátu tímu | 1d? | 2010-10-04 | 2010-10-04 |  | 58d |  | PB | 8h |
| 56 | 1.7.2 | Web prezentácia | 6d? | 2010-10-06 | 2010-10-12 |  | 51d | start no earlier than 2010-10-06 | MB | 48h |
| 57 | 1.7.3 | Štábna kultúra | 6d? | 2010-10-06 | 2010-10-12 |  | 51d | finish no earlier than 2010-10-12 | OU | 48h |
| 58 | 1.7.4 | Vypracovanie zápisu z 1. stretnutia | 4d? | 2010-09-29 | 2010-10-02 |  | 59d | finish no earlier than 2010-10-02 | OU | 32h |
| 59 | 1.7.5 | Vypracovanie zápisu z 2. stretnutia | 4d? | 2010-10-06 | 2010-10-09 |  | 53d | finish no earlier than 2010-10-09 | OU | 32h |
| 60 | 1.7.6 | Vypracovanie zápisu z 3. stretnutia | 4d? | 2010-10-13 | 2010-10-16 |  | 47d | start no earlier than 2010-10-13 | RS | 32h |
| 61 | 1.7.7 | Vypracovanie zápisu z 4. stretnutia | 4d? | 2010-10-20 | 2010-10-23 |  | 41d | start no earlier than 2010-10-20 | RS | 32h |
| 62 | 1.7.8 | Vypracovanie zápisu z 5. stretnutia | 4d? | 2010-10-27 | 2010-10-30 |  | 35d | start no earlier than 2010-10-27 |  |  |
| 63 | 1.7.9 | Vypracovanie zápisu z 6. stretnutia | 4d? | 2010-11-03 | 2010-11-06 |  | 29d | start no earlier than 2010-11-03 |  |  |
| 64 | 1.7.10 | Vypracovanie zápisu z 7. stretnutia | 4d? | 2010-11-10 | 2010-11-13 |  | 23d | start no earlier than 2010-11-10 |  |  |
| 65 | 1.7.11 | Vypracovanie zápisu z 8. stretnutia | 4d? | 2010-11-17 | 2010-11-20 |  | 17d | start no earlier than 2010-11-17 |  |  |
| 66 | 1.7.12 | Vypracovanie zápisu z 9. stretnutia | 4d? | 2010-11-24 | 2010-11-27 |  | 11d | start no earlier than 2010-11-24 |  |  |
| 67 | 1.7.13 | Vypracovanie zápisu z 10. stretnutia | 4d? | 2010-12-01 | 2010-12-04 |  | 5d | start no earlier than 2010-12-01 |  |  |
| 68 | 1.7.14 | Ukončenie prác prvého semestra | 1d? | 2010-12-10 | 2010-12-10 |  | 0d | start no earlier than 2010-12-10 | RS | 8h |
